# ECE 480 - Team 2

Schedule from MS Project, 2010-09-14 to 2010-12-15, A marks actual dates.
Michigan State University College of Engineering

## Calendars

- Standard: Mon-Fri 08:00-12:00, 13:00-17:00; Sat-Sun off.

## Resources

| Resource |
| --- |
| Felix |
| Jon |
| Matt |
| Nick |
| Li |
| "Nick |
| Felix" |
| b |

## Schedule

| ID | WBS | Task | Type | Duration | Start | Finish | Predecessors | Complete | Constraint | Resources | Work | Actual work |
| --- | --- | --- | --- | --- | --- | --- | --- | --- | --- | --- | --- | --- |
| 1 | 1 | **Project Definition** |  | 4d | 2010-09-14 A | 2010-09-17 A |  | 100% |  | b | 32h |  |
| 2 | 1.1 | Initial meeting with Sponsor |  | 1d | 2010-09-14 A | 2010-09-14 A |  | 100% | start no earlier than 2010-09-14 |  |  |  |
| 3 | 1.2 | Explore and discuss options |  | 2d | 2010-09-15 A | 2010-09-16 A | 2 | 100% |  |  |  |  |
| 4 | 1.3 | Initial meeting with Facilitator |  | 1d | 2010-09-17 A | 2010-09-17 A | 3 | 100% | start no earlier than 2010-09-17 |  |  |  |
| 5 | 1.4 | Planning done | milestone | 0d | 2010-09-17 A | 2010-09-17 A | 4 | 100% | start no earlier than 2010-09-17 |  |  |  |
| 6 | 2 | **Research possible interfaces** |  | 6d | 2010-09-20 A | 2010-09-27 A | 5 | 100% |  |  | 64h | 64h |
| 7 | 2.1 | LEGO Mindstorm |  | 2d | 2010-09-20 A | 2010-09-21 A |  | 100% | start no earlier than 2010-09-20 | Jon | 16h | 16h |
| 8 | 2.2 | LabVIEW |  | 1d | 2010-09-22 A | 2010-09-22 A | 7 | 100% |  | Matt; Nick | 16h | 16h |
| 9 | 2.3 | Robot C |  | 2d | 2010-09-23 A | 2010-09-24 A | 8 | 100% |  | Felix; Li | 32h | 32h |
| 10 | 2.4 | Pick Interface | milestone | 0d | 2010-09-27 A | 2010-09-27 A | 9 | 100% |  |  |  |  |
| 11 | 3 | Aquired Macine | milestone | 0d | 2010-09-27 A | 2010-09-27 A |  | 100% | start no earlier than 2010-09-27 |  |  |  |
| 12 | 4 | **Testing Phase** |  | 11d | 2010-09-28 A | 2010-10-12 A | 11 | 100% |  |  | 216h | 216h |
| 13 | 4.1 | Test Run & Diagnostics |  | 2d | 2010-09-28 A | 2010-09-29 A |  | 100% | start no earlier than 2010-09-28 | Nick; Matt; Felix; Li; Jon | 80h | 80h |
| 14 | 4.2 | Begin Proposal |  | 2d | 2010-09-30 A | 2010-10-01 A | 13 | 100% |  | Jon; Felix | 32h | 32h |
| 15 | 4.3 | Submit Pre-proposal | milestone | 0d | 2010-10-01 A | 2010-10-01 A | 14 | 100% |  | Jon |  |  |
| 16 | 4.4 | Perchase LEGO NXP |  | 4d | 2010-10-01 A | 2010-10-06 A |  | 100% | start no earlier than 2010-10-01 |  |  |  |
| 17 | 4.5 | Test LEGO Motors |  | 2d | 2010-10-07 A | 2010-10-08 A | 16 | 100% |  | Jon; Nick; Matt; Felix; Li | 80h | 80h |
| 18 | 4.6 | Order Rollers & Touch Sensors |  | 2d | 2010-10-08 A | 2010-10-11 A |  | 100% | start no earlier than 2010-10-08 | Jon | 16h | 16h |
| 19 | 4.7 | Test new rollers |  | 1d | 2010-10-12 A | 2010-10-12 A | 18 | 100% | start no earlier than 2010-10-12 | Jon | 8h | 8h |
| 20 | 5 | **Begin Preliminary Interfacing** |  | 3d | 2010-10-11 A | 2010-10-13 A | 17 | 100% |  |  | 72h | 72h |
| 21 | 5.1 | Learn LEGO Mindstorm |  | 1d | 2010-10-11 A | 2010-10-11 A |  | 100% | start no earlier than 2010-10-11 | Matt; Jon; Nick; Li; Felix | 40h | 40h |
| 22 | 5.2 | Check communications for NXT & PICs |  | 2d | 2010-10-12 A | 2010-10-13 A | 21 | 100% |  | Matt; Nick | 32h | 32h |
| 23 | 6 | **Presentation & Proposal** |  | 14d | 2010-10-04 A | 2010-10-21 A | 14 | 100% |  |  | 264h | 264h |
| 24 | 6.1 | Prepare slides based on proposal |  | 1d | 2010-10-04 A | 2010-10-04 A |  | 100% | start no earlier than 2010-10-04 | Felix | 8h | 8h |
| 25 | 6.2 | Feedback on Pre-proposal & Slides by Dr. Peng |  | 1d | 2010-10-11 A | 2010-10-11 A | 24 | 100% | start no earlier than 2010-10-11 |  |  |  |
| 26 | 6.3 | Practice Presentation |  | 3d | 2010-10-13 A | 2010-10-15 A | 25 | 100% | start no earlier than 2010-10-13 | Nick; Matt; Li; Jon; Felix | 120h | 120h |
| 27 | 6.4 | Give Presentation | milestone | 0d | 2010-10-18 A | 2010-10-18 A | 26 | 100% | start no earlier than 2010-10-18 | Nick; Matt; Li; Jon; Felix |  |  |
| 28 | 6.5 | Finish Proposal |  | 3d | 2010-10-19 A | 2010-10-21 A | 27 | 100% | start no earlier than 2010-10-19 | Felix; Matt; Li; Jon; Nick | 120h | 120h |
| 29 | 6.6 | Final Proposal | milestone | 0d | 2010-10-21 A | 2010-10-21 A | 28 | 100% |  |  |  |  |
| 30 | 6.7 | Work on Brochure |  | 2d | 2010-10-12 A | 2010-10-13 A |  | 100% | start no earlier than 2010-10-12 | Matt | 16h | 16h |
| 31 | 6.8 | Turn in brochure | milestone | 0d | 2010-10-15 A | 2010-10-15 A | 30 | 100% | start no earlier than 2010-10-15 | Matt |  |  |

| ID | WBS | Task | Type | Duration | Start | Finish | Predecessors | Complete | Remaining | Total slack | Free slack | Constraint | Resources | Work | Actual work |
| --- | --- | --- | --- | --- | --- | --- | --- | --- | --- | --- | --- | --- | --- | --- | --- |
| 32 | 7 | **Begin Project Build** |  | 15d | 2010-10-25 A | 2010-11-12 | 29 | 80% | 3d | 23d |  |  |  | 168h | 144h |
| 33 | 7.1 | Replace PIC with NXT and I2C |  | 3d | 2010-10-25 A | 2010-10-27 A |  | 100% |  |  |  | start no earlier than 2010-10-25 | Matt; Nick | 48h | 48h |
| 34 | 7.2 | Build Prototype Design |  | 3d | 2010-10-28 A | 2010-11-01 A | 33 | 100% |  |  |  |  | Jon; Nick | 48h | 48h |
| 35 | 7.3 | Order New Guilliotine Cutter |  | 2d | 2010-11-02 A | 2010-11-03 A | 34 | 100% |  |  |  |  | Li | 16h | 16h |
| 36 | 7.4 | Install and Test Cutter |  | 2d | 2010-11-04 A | 2010-11-05 A | 35 | 100% |  |  |  |  | Jon | 16h | 16h |
| 37 | 7.5 | Audio Circuit |  | 3d | 2010-11-08 | 2010-11-10 | 36 |  |  | 25d |  |  | Li | 24h |  |
| 38 | 7.6 | Power Supply and New Box Design |  | 2d | 2010-11-11 A | 2010-11-12 A | 37 | 100% |  |  |  |  | Felix | 16h | 16h |
| 39 | 8 | **Final Programming** |  | 7d | 2010-11-15 A | 2010-11-23 | 38 | 71% | 2d | 4d |  |  |  | 56h | 40h |
| 40 | 8.1 | LED Circuit |  | 1d | 2010-11-15 A | 2010-11-15 A |  | 100% |  |  |  |  | Nick | 8h | 8h |
| 41 | 8.2 | Motors and Drivers |  | 4d | 2010-11-16 A | 2010-11-19 A | 40 | 100% |  |  |  |  | Jon | 32h | 32h |
| 42 | 8.3 | Cutter Activation |  | 2d | 2010-11-22 | 2010-11-23 | 41 |  |  | 4d | 0d |  | Jon | 16h |  |
| 43 | 9 | **Finishing Touches** |  | 15d | 2010-11-24 A | 2010-12-14 | 42 | 27% | 11d | 0d |  |  |  | 312h | 64h |
| 44 | 9.1 | Finalize Appearance |  | 4d | 2010-11-24 A | 2010-11-29 A |  | 100% |  |  |  |  | Felix; Li | 64h | 64h |
| 45 | 9.2 | Poster |  | 6d | 2010-11-30 | 2010-12-07 | 44 |  |  | 0d |  |  | Nick | 48h |  |
| 46 | 9.3 | Final Report |  | 5d | 2010-12-08 | 2010-12-14 | 45 |  |  | 0d |  |  | Nick; Matt; Li; Jon; Felix | 200h |  |
| 47 | 9.4 | Poster Due | milestone | 0d | 2010-12-07 | 2010-12-07 | 45 |  |  | 5d |  | start no earlier than 2010-12-06 |  |  |  |
| 48 | 9.5 | Final Report Due | milestone | 0d | 2010-12-14 | 2010-12-14 | 46 |  |  | 0d |  |  |  |  |  |
| 49 | 10 | **Final Testing** |  | 9d | 2010-11-24 A | 2010-12-06 | 42 | 67% | 3d | 6d |  |  |  | 72h | 48h |
| 50 | 10.1 | Cutter Working |  | 2d | 2010-11-24 A | 2010-11-25 A |  | 100% |  |  |  |  | Li | 16h | 16h |
| 51 | 10.2 | Accuracy & Precision |  | 2d | 2010-11-26 A | 2010-11-29 A | 50 | 100% |  |  |  |  | Matt | 16h | 16h |
| 52 | 10.3 | Feeding System Runs Smoothly |  | 2d | 2010-11-30 A | 2010-12-01 A | 51 | 100% |  |  |  |  | Jon | 16h | 16h |
| 53 | 10.4 | Soldering Circuits |  | 1d | 2010-12-02 | 2010-12-02 | 52 |  |  | 6d | 0d |  | Matt; Nick | 16h |  |
| 54 | 10.5 | Document Circuits |  | 1d | 2010-12-03 | 2010-12-03 | 53 |  |  | 6d | 0d |  | Felix | 8h |  |
| 55 | 10.6 | Have Project Completed | milestone | 0d | 2010-12-03 | 2010-12-03 | 54 |  |  | 6d | 0d | start no earlier than 2010-12-03 |  |  |  |
| 56 | 10.7 | Test Run |  | 1d | 2010-12-06 | 2010-12-06 | 55 |  |  | 6d |  | start no earlier than 2010-12-06 |  |  |  |
| 57 | 11 | DESIGN DAY |  | 1d | 2010-12-15 | 2010-12-15 | 43, 49 |  |  | 0d |  | start no earlier than 2010-12-10 | Nick; Matt; Jon; Li; Felix | 40h |  |
